# Spring 2008 Schedule~671

Schedule from MS Project, 2008-04-01 to 2008-06-06, A marks actual dates.

## Calendars

- Standard: Mon-Fri 08:00-12:00, 13:00-17:00; Sat-Sun off. Exceptions (off unless hours are given): 2008-04-06 08:00-12:00, 13:00-17:00, 2008-04-12 to 2008-04-13 08:00-12:00, 13:00-17:00, 2008-04-19 08:00-12:00, 13:00-17:00.

## Schedule

| ID | Task | Duration | Start | Finish | Predecessors | Complete | Remaining | Total slack | Free slack | Constraint |
| --- | --- | --- | --- | --- | --- | --- | --- | --- | --- | --- |
| 1 | Build all unary gates in lab | 0.8w? | 2008-04-01 A | 2008-04-04 A |  | 100% |  |  |  | finish no earlier than 2008-04-04 |
| 2 | Build a 3:1 multiplexer | 2.5d? | 2008-04-03 A | 2008-04-07 A | 1 | 100% |  |  |  |  |
| 3 | Antonio learn Ltspice | 3d? | 2008-04-02 A | 2008-04-04 A |  | 100% |  |  |  | start no earlier than 2008-04-02 |
| 4 | Chirag learn and setup git | 10d? | 2008-04-02 A | 2008-04-13 A |  | 100% |  |  |  | finish no earlier than 2008-04-13 |
| 5 | Himanshu administrative tasks | 13d? | 2008-04-01 A | 2008-04-14 A |  | 100% |  |  |  | finish no earlier than 2008-04-14 |
| 6 | Expression evaluator working | 1.4w? | 2008-04-01 A | 2008-04-09 A |  | 100% |  |  |  | finish no earlier than 2008-04-09 |
| 7 | Senior project proposal due | 1d? | 2008-04-07 A | 2008-04-07 A |  | 100% |  |  |  | start no earlier than 2008-04-07 |
| 8 | Build dyadic gates in lab | 0.5w? | 2008-04-08 A | 2008-04-10 A |  | 100% |  |  |  | start no earlier than 2008-04-09 |
| 9 | Build ternary cycling gate | 3d? | 2008-04-16 A | 2008-04-18 A |  | 100% |  |  |  | finish no earlier than 2008-04-18 |
| 10 | Wiki server RAID 0+1->1 disk upgrades | 7d? | 2008-04-06 A | 2008-04-12 A |  | 100% |  |  |  | start no earlier than 2008-04-06 |
| 11 | Honors Open House - decide on timeslot | 11d? | 2008-04-09 A | 2008-04-19 A |  | 100% |  |  |  | finish no earlier than 2008-04-19 |
| 12 | Honors Open House Poster Due | 9d? | 2008-04-08 A | 2008-04-16 A |  | 100% |  |  |  | finish no earlier than 2008-04-16 |
| 13 | Instruction-level simulator working | 5.5d? | 2008-04-10 A | 2008-04-15 A | 6 | 100% |  |  |  |  |
| 14 | Honors Open House Presentation 1:30-2 | 1d? | 2008-04-19 A | 2008-04-19 A |  | 100% |  |  |  | finish no earlier than 2008-04-19 |
| 15 | Simulate all tri-flop circuits | 16d? | 2008-04-03 A | 2008-04-21 A |  | 100% |  |  |  | finish no earlier than 2008-04-21 |
| 16 | Build dtflop-ms tri-flop circuit | 9.5d? | 2008-04-10 A | 2008-04-19 A |  | 100% |  |  |  | finish no earlier than 2008-04-19 |
| 17 | Circuit layout program functional | 8d? | 2008-04-11 A | 2008-04-18 A |  | 100% |  |  |  | finish no earlier than 2008-04-18 |
| 18 | Order and receive purchase #3 | 17.5d? | 2008-04-02 A | 2008-04-21 A |  | 100% |  |  |  | finish no earlier than 2008-04-16 |
| 19 | Design SP3T footprint for FreePCB | 5d? | 2008-04-21 A | 2008-04-25 A |  | 100% |  |  |  | finish no earlier than 2008-04-25 |
| 20 | Label all nodes in LTspice properly | 1d? | 2008-04-21 A | 2008-04-21 A |  | 100% |  |  |  | finish no earlier than 2008-05-02 |
| 21 | Decide about reading textbook | 1d? | 2008-04-28 A | 2008-04-28 A |  | 100% |  |  |  | finish no earlier than 2008-04-28 |
| 22 | SWROM PCB layout and routing | 5d? | 2008-04-24 A | 2008-04-30 A |  | 100% |  |  |  | finish no earlier than 2008-04-30 |
| 23 | Design and simulate ALU | 13d? | 2008-04-21 A | 2008-05-07 A |  | 100% |  |  |  | finish no earlier than 2008-05-07 |
| 24 | Expression creator functional | 7d | 2008-04-21 A | 2008-04-29 A |  | 100% |  |  |  | finish no earlier than 2008-04-29 |
| 25 | Order PCB for 9-bit SWROM | 10d? | 2008-04-28 A | 2008-05-09 A |  | 100% |  |  |  | start no earlier than 2008-04-28 |
| 26 | Retest dtflop-ms in lab | 6d? | 2008-04-28 A | 2008-05-05 A |  | 100% |  |  |  | finish no earlier than 2008-05-05 |
| 27 | Base 3 converter functional | 11d | 2008-04-21 A | 2008-05-05 |  | 73% | 3d | 24d |  | finish no earlier than 2008-05-05 |
| 28 | Layout memory board | 2d? | 2008-05-05 | 2008-05-06 |  |  |  | 21d |  | finish no earlier than 2008-05-06 |
| 29 | Order PCB of memory board | 2d? | 2008-05-07 | 2008-05-08 | 28 |  |  | 21d |  | finish no earlier than 2008-05-07 |
| 30 | Built & test sign detector | 5d? | 2008-05-05 | 2008-05-09 |  |  |  | 20d |  | finish no earlier than 2008-05-09 |
| 31 | Layout control board | 6d? | 2008-05-05 | 2008-05-12 |  |  |  | 19d |  | finish no earlier than 2008-05-12 |
| 32 | CMP instruction working | 6d? | 2008-05-05 | 2008-05-12 |  |  |  | 18d | 0d | finish no earlier than 2008-05-12 |
| 33 | Order PCB of control board | 1d? | 2008-05-13 | 2008-05-13 | 32 |  |  | 18d |  | start no earlier than 2008-05-12 |
| 34 | Test 9-bit SWROM with cycling gate | 5d? | 2008-05-12 | 2008-05-16 | 23 |  |  | 15d |  | start no earlier than 2008-05-12 |
| 35 | Photoshop VTC curve | 15d? | 2008-04-28 | 2008-05-16 |  |  |  | 15d |  | start no earlier than 2008-04-28 |
| 36 | BE instruction working | 5d? | 2008-05-12 | 2008-05-18 |  |  |  | 15d |  | finish no earlier than 2008-05-18 |
| 37 | Layout ALU board | 11d? | 2008-05-05 | 2008-05-19 |  |  |  | 14d |  | finish no earlier than 2008-05-19 |
| 38 | High-level language to asm compiler | 22d? | 2008-04-22 | 2008-05-21 |  |  |  | 12d |  | start no earlier than 2008-04-22 |
| 39 | Chirag - Ch1: Boolean Logic | 11d? | 2008-04-28 | 2008-05-12 |  |  |  | 19d |  | finish no earlier than 2008-05-12 |
| 40 | Jeff - Ch4: Machine Language | 6d? | 2008-04-28 A | 2008-05-05 A |  | 100% |  |  |  | finish no earlier than 2008-05-05 |
| 41 | Antonio - Ch7: VM I: Stack Arithmetic | 11d? | 2008-04-28 | 2008-05-12 |  |  |  | 19d |  | finish no earlier than 2008-05-12 |
| 42 | Jeff - Ch5: Computer Architecture | 6d? | 2008-05-05 | 2008-05-12 |  |  |  | 19d |  | finish no earlier than 2008-05-12 |
| 43 | Honors Progress Report 2 Due | 2d | 2008-05-06 | 2008-05-07 |  |  |  | 22d |  | finish no earlier than 2008-05-07 |
| 44 | Chirag - Ch2: Boolean Arithmetic | 6d? | 2008-05-05 | 2008-05-12 |  |  |  | 19d |  | finish no earlier than 2008-05-12 |
| 45 | Antonio - Ch8: VM II: Program Control | 6d? | 2008-05-05 | 2008-05-12 |  |  |  | 19d |  | finish no earlier than 2008-05-12 |
| 46 | Antonio - Ch9: High-level Language | 6d? | 2008-05-05 | 2008-05-12 |  |  |  | 19d |  | finish no earlier than 2008-05-12 |
| 47 | Chirag install git on MacBook | 6d? | 2008-05-05 | 2008-05-12 |  |  |  | 19d |  | start no earlier than 2008-05-05 |
| 48 | eval.py return 0, i, 1 | 11d? | 2008-04-28 | 2008-05-12 |  |  |  | 19d |  | finish no earlier than 2008-05-12 |
| 49 | eval.py, allow literals 0, i, 1 | 11d? | 2008-04-28 | 2008-05-12 |  |  |  | 19d |  | finish no earlier than 2008-05-12 |
| 50 | eval.py, allow trit vectors as inputs | 11d? | 2008-04-28 | 2008-05-12 |  |  |  | 19d |  | finish no earlier than 2008-05-12 |
| 51 | Jeff - Ch6: Assembler | 6d? | 2008-05-12 | 2008-05-19 |  |  |  | 14d |  | finish no earlier than 2008-05-19 |
| 52 | Chirag - Ch3: Sequential Logic | 6d? | 2008-05-12 | 2008-05-19 |  |  |  | 14d |  | finish no earlier than 2008-05-19 |
| 53 | Integration | 7.5d? | 2008-05-08 | 2008-05-19 | 23 |  |  | 14.5d |  |  |
| 54 | CPU simulation, allow graceful termination | 11d? | 2008-05-05 | 2008-05-19 |  |  |  | 14d |  | finish no earlier than 2008-05-19 |
| 55 | Antonio - Ch10: Compiler I: Syntax Analysis | 11d? | 2008-05-12 | 2008-05-26 |  |  |  | 9d |  | finish no earlier than 2008-05-26 |
| 56 | Antonio - Ch11: Compiler II: Code Generation | 11d? | 2008-05-12 | 2008-05-26 |  |  |  | 9d |  | finish no earlier than 2008-05-26 |
| 57 | Senior project spec & schedule draft due | 6d? | 2008-05-16 | 2008-05-23 |  |  |  | 10d |  | finish no earlier than 2008-05-23 |
| 58 | Prepare for CSC IAB Presentation | 9d? | 2008-05-20 | 2008-05-30 |  |  |  | 5d |  | finish no earlier than 2008-05-30 |
| 59 | Honors Progress Report Due | 1d? | 2008-05-29 | 2008-05-29 |  |  |  | 6d |  | finish no earlier than 2008-05-29 |
| 60 | Antonio - Ch12: Operating System | 6d? | 2008-05-26 | 2008-06-02 |  |  |  | 4d |  | finish no earlier than 2008-06-02 |
| 61 | Honors Final Report Due (9 pm) | 5d? | 2008-06-02 | 2008-06-06 |  |  |  | 0d |  | finish no earlier than 2008-06-06 |
| 62 | Senior project spec & schedule final due | 6d? | 2008-05-30 | 2008-06-06 |  |  |  | 0d |  | finish no earlier than 2008-06-06 |

Notes:
- 18: 2008-04-03 Jeff requested quote #3 from Digi-Key / 2008-04-08 Chirag gave quote #3 to Cindy to order / 2008-04-14 Contacted Debbie Tuson, extension 6-6116 on campus, said she would give the order to the purchasing girl this morning
